# CA 1ERA ETAPA

Schedule from MS Project, 2005-01-01 to 2005-05-30.
emv

## Calendars

- Estándar: Mon-Sun 08:00-14:00, 15:00-17:00. Exceptions (off unless hours are given): 2005-01-01 to 2005-01-31 08:00-14:00, 15:00-17:00.

## Schedule

| ID | WBS | Task | Type | Duration | Start | Finish | Predecessors | Baseline start | Baseline finish | Baseline duration | Total slack | Free slack | Constraint |
| --- | --- | --- | --- | --- | --- | --- | --- | --- | --- | --- | --- | --- | --- |
| 1 | 1 | **CONSTRUCCION DE LA OBRA** |  | 150d | 2005-01-01 | 2005-05-30 |  | 2004-07-01 | 2004-12-07 | 160d | 0d |  |  |
| 2 | 1.1 | INICIO DE OBRA | milestone | 0d | 2005-01-03 | 2005-01-03 |  | 2004-07-01 | 2004-07-01 | 0d | 0d |  | must start on 2005-01-03 |
| 3 | 1.2 | **OBRAS PROVISIONALES** |  | 5d | 2005-01-03 | 2005-01-07 |  | 2004-07-01 | 2004-07-01 | 1d | 68d |  |  |
| 4 | 1.2.1 | ALMACEN, OFICINAS, CASETA DE GUARDIANIA Y COMEDOR |  | 5d | 2005-01-03 | 2005-01-07 | 2 | 2005-01-01 | 2005-01-02 | 2d | 68d | 0d |  |
| 5 | 1.2.2 | CERCO PERIMETRICO ELEMENTOS PREFABRICADOS MADERA |  | 2d | 2005-01-03 | 2005-01-04 | 4SS |  |  |  | 145d |  |  |
| 6 | 1.2.3 | CARTEL DE OBRA |  | 1d | 2005-01-03 | 2005-01-03 | 4SS | 2004-07-01 | 2004-07-01 | 1d | 147d |  |  |
| 7 | 1.3 | **TRABAJOS PRELIMINARES** |  | 49d | 2005-01-03 | 2005-02-20 |  | 2004-07-01 | 2004-07-02 | 2d | 79d |  |  |
| 8 | 1.3.1 | DEMOLICION DE CIMIENTO EXISTENTE DE CONCRETO |  | 5d | 2005-01-03 | 2005-01-07 | 4SS |  |  |  | 142d |  |  |
| 9 | 1.3.2 | DEMOLICION ESCALERA DE CONCRETO C/EQUIPO |  | 3d | 2005-01-13 | 2005-01-15 | 4SS+10d |  |  |  | 132d | 0d |  |
| 10 | 1.3.3 | DEMOLICION MURO LADRILLO ARCILLA SOGA |  | 5d | 2005-01-10 | 2005-01-14 | 4SS+7d |  |  |  | 135d |  |  |
| 11 | 1.3.4 | DEMOLICION DE PISO Co. INC. FALSOPISO e=12.5cm C/EQUIPO |  | 5d | 2005-01-13 | 2005-01-17 | 9SS |  |  |  | 132d |  |  |
| 12 | 1.3.5 | DEMOLICION COLUMNA DECONCRETO C/EQUIPO |  | 5d | 2005-02-09 | 2005-02-13 | 21 |  |  |  | 99d | 0d |  |
| 13 | 1.3.6 | DESMONTAJE Y REUBICACION DE ARCO FULBITO METALICO |  | 5d | 2005-01-08 | 2005-01-12 | 4 |  |  |  | 138d |  |  |
| 14 | 1.3.7 | DESMONTAJE APARATO SANITARIO (INODOROS) |  | 2d | 2005-01-08 | 2005-01-09 | 4 |  |  |  | 99d | 0d |  |
| 15 | 1.3.8 | DESMONTAJE ACCESORIOS SANITARIOS (GRIFERIA Y OTROS) |  | 2d | 2005-01-08 | 2005-01-09 | 4 |  |  |  | 141d |  |  |
| 16 | 1.3.9 | DESMONTAJE PUERTA MADERA |  | 2d | 2005-01-08 | 2005-01-09 | 4 |  |  |  | 141d |  |  |
| 17 | 1.3.10 | DESMONTAJE TABLEROS PARA BASQUET |  | 2d | 2005-01-23 | 2005-01-24 | 4SS+20d |  |  |  | 125d |  |  |
| 18 | 1.3.11 | RETIRO DE ZOCALO (H=1.20M) |  | 7d | 2005-02-14 | 2005-02-20 | 12 |  |  |  | 99d |  |  |
| 19 | 1.3.12 | RETIRO DE CANTONERAS METALICAS |  | 1d | 2005-01-08 | 2005-01-08 | 4 |  |  |  | 142d |  |  |
| 20 | 1.3.13 | PICADO DE PISOS DE CONCRETO |  | 5d | 2005-01-08 | 2005-01-12 | 4 |  |  |  | 138d |  |  |
| 21 | 1.3.14 | APUNTALAMIENTO DE TECHO ALIGERADO EXISTENTE |  | 30d | 2005-01-10 | 2005-02-08 | 14 |  |  |  | 99d | 0d |  |
| 22 | 1.3.15 | DEMOLICION PATIO Co. E=10cmC/EQUIPO |  | 5d | 2005-01-08 | 2005-01-12 | 4 |  |  |  | 138d |  |  |
| 23 | 1.3.16 | DESMONTAJE TECHO LIVIANO C/ESTRUCTURA METALICA |  | 3d | 2005-01-11 | 2005-01-13 | 24 |  |  |  | 137d |  |  |
| 24 | 1.3.17 | DESMONTAJE TABIQUES DE MADERA INC. PUERTAS Y VENTANAS |  | 3d | 2005-01-08 | 2005-01-10 | 4 |  |  |  | 137d | 0d |  |
| 25 | 1.3.18 | MOBILIZACION Y DESMOVILIZACION DE EQUIPOS |  | 1d | 2005-01-03 | 2005-01-03 | 4SS |  |  |  | 146d |  |  |
| 26 | 1.3.19 | LIMPIEZA DEL TERRENO MANUAL |  | 3d | 2005-01-03 | 2005-01-05 | 4SS |  |  |  | 144d |  |  |
| 27 | 1.3.20 | TRAZO Y REPLANTEO |  | 7d | 2005-01-03 | 2005-01-09 | 4SS | 2005-01-06 | 2005-01-11 | 6d | 83d | 0d |  |

| ID | WBS | Task | Duration | Start | Finish | Predecessors | Baseline start | Baseline finish | Baseline duration | Total slack | Free slack | Constraint |
| --- | --- | --- | --- | --- | --- | --- | --- | --- | --- | --- | --- | --- |
| 28 | 1.4 | **MOVIMIENTO DE TIERRAS** | 59d | 2005-01-05 | 2005-03-04 |  | 2005-01-09 | 2005-01-26 | 18d | 79d |  |  |
| 29 | 1.4.1 | EXCAV. DE ZANJAS Y ZAPATAS RT < 2 KG/CM2 | 25d | 2005-01-10 | 2005-02-03 | 30 | 2005-01-12 | 2005-01-16 | 5d | 83d | 0d |  |
| 30 | 1.4.2 | EXCAVACIONES MASIVAS | 5d | 2005-01-05 | 2005-01-09 | 27SS+2d | 2004-07-02 | 2004-07-02 | 1d | 83d | 0d |  |
| 31 | 1.4.3 | RELLENO, AFIRMADO COMPACTADO C/EQUIPO MAT/PROPIO | 25d | 2005-02-08 | 2005-03-04 | 39SS+3d | 2004-07-11 | 2004-07-13 | 3d | 75d | 0d | start no earlier than 2005-01-19 |
| 32 | 1.4.4 | ACARREO INTERNO, PROCEDENTE DE EXCAVACION | 25d | 2005-01-11 | 2005-02-04 | 29SS+1d | 2004-07-03 | 2004-07-12 | 10d | 114d | 0d |  |
| 33 | 1.4.5 | ELIMINACION MATERIAL EXCEDENTE C/MAQUINA DIST < 10km | 15d | 2005-01-16 | 2005-01-30 | 32SS+5d | 2004-07-08 | 2004-07-20 | 13d | 120d |  |  |
| 34 | 1.5 | **CONCRETO SIMPLE** | 96d | 2005-01-18 | 2005-04-23 |  | 2005-01-12 | 2005-03-09 | 57d | 26d |  |  |
| 35 | 1.5.1 | SUBCIMIENTO/SUBZAPATAS, MEZCLA 1:12 + 30 % P.G. | 10d | 2005-01-18 | 2005-01-27 | 29SS+4d | 2004-07-09 | 2004-07-09 | 1d | 79d | 0d | start no earlier than 2005-01-18 |
| 36 | 1.5.2 | SOLADO DE CONCRETO E=2" C:H 1:12 | 6d | 2005-01-18 | 2005-01-23 | 35SS | 2004-07-10 | 2004-07-13 | 4d | 115d | 0d |  |
| 37 | 1.5.3 | SOLADO DE CONCRETO E=8" C:H 1:12 | 6d | 2005-01-18 | 2005-01-23 | 35SS |  |  |  | 84d | 0d |  |
| 38 | 1.5.4 | CIMIENTOS CORRIDOS 1:10 + 30 P.G. F'c >= 100kg/cm2 | 14d | 2005-01-25 | 2005-02-07 | 35FS-3d | 2004-07-12 | 2004-07-14 | 3d | 79d | 0d |  |
| 39 | 1.5.5 | SOBRECIMIENTOS CONCRETO C:H 1:8 + 25% P.M. | 6d | 2005-02-05 | 2005-02-10 | 40SS+1d |  |  |  | 79d | 0d |  |
| 40 | 1.5.6 | ENCOFRADO Y DESENCOFRADO DE SOBRECIMIENTOS | 5d | 2005-02-04 | 2005-02-08 | 38FS-4d | 2004-07-20 | 2004-07-20 | 1d | 79d | 0d |  |
| 41 | 1.5.7 | FALSO PISO CONCRETO MEZCLA, 1:8 E=4" | 19d | 2005-04-05 | 2005-04-23 | 59FS+10d |  |  |  | 0d |  |  |
| 42 | 1.6 | **CONCRETO ARMADO** | 107d | 2005-01-01 | 2005-04-17 |  | 2004-07-01 | 2004-08-29 | 60d | 15d |  |  |
| 43 | 1.6.1 | **ZAPATAS** | 11d | 2005-01-24 | 2005-02-03 |  | 2004-07-09 | 2004-07-09 | 1d | 116d |  |  |
| 44 | 1.6.1.1 | CONCRETO EN ZAPATAS F'C= 210 KG/CM2 | 9d | 2005-01-26 | 2005-02-03 | 45SS+2d | 2004-07-09 | 2004-07-09 | 0.5d | 115d |  |  |
| 45 | 1.6.1.2 | ACERO DE REFUERZO Fy= 4200 kg/cm2 | 7d | 2005-01-24 | 2005-01-30 | 36 | 2004-07-09 | 2004-07-09 | 0.5d | 115d | 0d |  |
| 46 | 1.6.2 | **VIGAS DE CIMENTACION** | 16d | 2005-02-08 | 2005-02-23 |  | 2004-07-10 | 2004-08-06 | 28d | 85d |  |  |
| 47 | 1.6.2.1 | VIGA DE CIMENTACION CONCRETO 210 KG/CM2 | 14d | 2005-02-10 | 2005-02-23 | 49SS+2d | 2004-08-04 | 2004-08-06 | 3d | 84d | 0d |  |
| 48 | 1.6.2.2 | VIGA DE CIMENTACION ENCOFRADO Y DESENCOFRADO | 16d | 2005-02-08 | 2005-02-23 | 38 | 2004-07-27 | 2004-08-03 | 8d | 84d | 0d |  |
| 49 | 1.6.2.3 | ACERO DE REFUERZO Fy= 4200 kg/cm2 | 12d | 2005-02-08 | 2005-02-19 | 48SS | 2004-07-10 | 2004-07-18 | 9d | 84d | 0d |  |
| 50 | 1.6.3 | **SOBRECIMIENTOS ARMADO** | 14d | 2005-02-21 | 2005-03-06 |  | 2004-07-10 | 2004-08-06 | 28d | 85d |  |  |
| 51 | 1.6.3.1 | SOBRECIMIENTOS REFORZADOS CONCRETO 210 KG/CM2 | 10d | 2005-02-24 | 2005-03-05 | 53SS+2d | 2004-08-04 | 2004-08-06 | 3d | 85d |  |  |
| 52 | 1.6.3.2 | SOBRECIMIENTOS REFORZADOS ENCOFRADO Y DESENCOFRADO | 14d | 2005-02-21 | 2005-03-06 | 47FS-3d | 2004-07-27 | 2004-08-03 | 8d | 84d | 0d |  |
| 53 | 1.6.3.3 | ACERO DE REFUERZO Fy= 4200 kg/cm2 | 10d | 2005-02-22 | 2005-03-03 | 52SS+1d | 2004-07-10 | 2004-07-18 | 9d | 85d | 0d |  |

| ID | WBS | Task | Duration | Start | Finish | Predecessors | Baseline start | Baseline finish | Baseline duration | Total slack | Free slack | Constraint |
| --- | --- | --- | --- | --- | --- | --- | --- | --- | --- | --- | --- | --- |
| 54 | 1.6.4 | **VIGAS** | 71d | 2005-01-07 | 2005-03-18 |  | 2004-08-14 | 2004-08-29 | 16d | 73d |  |  |
| 55 | 1.6.4.1 | VIGAS DE CONCRETO 210 | 10d | 2005-03-06 | 2005-03-15 | 59SS | 2004-08-25 | 2004-08-26 | 1.3d | 40d | 0d |  |
| 56 | 1.6.4.2 | VIGAS ENCOFRADO Y DESENCOFRADO | 22d | 2005-01-07 | 2005-01-28 | 60FF | 2004-08-14 | 2004-08-28 | 15d | 121d | 0d |  |
| 57 | 1.6.4.3 | ACERO DE REFUERZO Fy= 4200 kg/cm2 | 16d | 2005-03-03 | 2005-03-18 | 61SS+1d | 2004-08-23 | 2004-08-29 | 7d | 72d |  |  |
| 58 | 1.6.5 | **LOSAS ALIGERADA** | 84d | 2005-01-01 | 2005-03-25 |  | 2004-08-14 | 2004-08-29 | 16d | 0d |  |  |
| 59 | 1.6.5.1 | LOSA ALIGERADA DE CONCRETO 210 | 20d | 2005-03-06 | 2005-03-25 | 61SS+4d | 2004-08-25 | 2004-08-26 | 1.3d | 0d |  |  |
| 60 | 1.6.5.2 | LOSA ALIGERADA ENCOFRADO Y DESENCOFRADO | 28d | 2005-01-01 | 2005-01-28 |  | 2004-08-14 | 2004-08-28 | 15d | 15d | 0d |  |
| 61 | 1.6.5.3 | ACERO DE REFUERZO Fy= 4200 kg/cm2 | 17d | 2005-03-02 | 2005-03-18 | 62SS+1d | 2004-08-23 | 2004-08-29 | 7d | 0d |  |  |
| 62 | 1.6.5.4 | LADRILLO PARA TECHO | 12d | 2005-03-01 | 2005-03-12 | 60SS+4d | 2005-03-07 | 2005-03-11 | 5d | 0d |  | start no earlier than 2005-03-01 |
| 63 | 1.6.6 | **LOSAS MACIZAS** | 13d | 2005-04-05 | 2005-04-17 |  | 2004-08-14 | 2004-08-29 | 16d | 43d |  |  |
| 64 | 1.6.6.1 | LOSA MACIZA DE CONCRETO 210 | 4d | 2005-04-14 | 2005-04-17 | 66 | 2004-08-25 | 2004-08-26 | 1.3d | 42d |  | start no earlier than 2005-02-27 |
| 65 | 1.6.6.2 | LOSA MACIZA ENCOFRADO Y DESENCOFRADO | 6d | 2005-04-05 | 2005-04-10 | 85 | 2004-08-14 | 2004-08-28 | 15d | 42d | 0d |  |
| 66 | 1.6.6.3 | ACERO DE REFUERZO Fy= 4200 kg/cm2 | 3d | 2005-04-11 | 2005-04-13 | 65 | 2004-08-23 | 2004-08-29 | 7d | 42d | 0d | start no earlier than 2005-02-25 |
| 67 | 1.6.7 | **CISTERNA** | 7d | 2005-01-24 | 2005-01-30 |  | 2004-08-14 | 2004-08-29 | 16d | 85d |  |  |
| 68 | 1.6.7.1 | CISTERNA DE CONCRETO 210 | 3d | 2005-01-27 | 2005-01-29 | 70SS+3d | 2004-08-25 | 2004-08-26 | 1.3d | 84d | 0d |  |
| 69 | 1.6.7.2 | CISTERNA ENCOFRADO Y DESENCOFRADO | 3d | 2005-01-28 | 2005-01-30 | 71 | 2004-08-14 | 2004-08-28 | 15d | 119d |  |  |
| 70 | 1.6.7.3 | ACERO DE REFUERZO Fy= 4200 kg/cm2 | 5d | 2005-01-24 | 2005-01-28 | 37 | 2004-08-23 | 2004-08-29 | 7d | 84d | 0d |  |
| 71 | 1.6.7.4 | COLOCACION DE WATER STOP DE 6" | 1d | 2005-01-27 | 2005-01-27 | 68SS |  |  |  | 119d | 0d |  |
| 72 | 1.6.8 | **TANQUE ELEVADO** | 4d | 2005-03-03 | 2005-03-06 |  | 2004-08-14 | 2004-08-29 | 16d | 85d |  |  |
| 73 | 1.6.8.1 | TANQUE ELEVADO DE CONCRETO 210 | 2d | 2005-03-04 | 2005-03-05 | 75SS+1d | 2004-08-25 | 2004-08-26 | 1.3d | 84d | 0d |  |
| 74 | 1.6.8.2 | TANQUE ELEVADO ENCOFRADO Y DESENCOFRADO | 2d | 2005-03-05 | 2005-03-06 | 73SS+1d | 2004-08-14 | 2004-08-28 | 15d | 84d |  |  |
| 75 | 1.6.8.3 | ACERO DE REFUERZO Fy= 4200 kg/cm2 | 2d | 2005-03-03 | 2005-03-04 | 68SS+35d | 2004-08-23 | 2004-08-29 | 7d | 84d | 0d |  |
| 76 | 1.6.9 | **ESCALERAS** | 8d | 2005-03-24 | 2005-03-31 |  | 2004-08-14 | 2004-08-29 | 16d | 48d |  |  |
| 77 | 1.6.9.1 | ESCALERAS DE CONCRETO 210 | 3d | 2005-03-29 | 2005-03-31 | 79 | 2004-08-25 | 2004-08-26 | 1.3d | 48d | 0d |  |
| 78 | 1.6.9.2 | ESCALERAS ENCOFRADO Y DESENCOFRADO | 4d | 2005-03-24 | 2005-03-27 | 59FS-2d | 2004-08-14 | 2004-08-28 | 15d | 48d | 0d |  |
| 79 | 1.6.9.3 | ACERO DE REFUERZO Fy= 4200 kg/cm2 | 3d | 2005-03-26 | 2005-03-28 | 78SS+2d | 2004-08-23 | 2004-08-29 | 7d | 48d | 0d |  |

| ID | WBS | Task | Duration | Start | Finish | Predecessors | Baseline start | Baseline finish | Baseline duration | Total slack | Free slack | Constraint |
| --- | --- | --- | --- | --- | --- | --- | --- | --- | --- | --- | --- | --- |
| 80 | 1.6.10 | **LAVADEROS CORRIDOS** | 8d | 2005-01-21 | 2005-01-28 |  | 2004-08-14 | 2004-08-29 | 16d | 122d |  |  |
| 81 | 1.6.10.1 | LAVADERO CORRIDO DE CONCRETO 210 | 4d | 2005-01-25 | 2005-01-28 | 83SS | 2004-08-25 | 2004-08-26 | 1.3d | 121d |  |  |
| 82 | 1.6.10.2 | LAVADERO CORRIDO ENCOFRADO Y DESENCOFRADO | 8d | 2005-01-21 | 2005-01-28 | 56FF | 2004-08-14 | 2004-08-28 | 15d | 121d |  |  |
| 83 | 1.6.10.3 | ACERO DE REFUERZO Fy= 4200 kg/cm2 | 4d | 2005-01-25 | 2005-01-28 | 56FF | 2004-08-23 | 2004-08-29 | 7d | 121d | 0d |  |
| 84 | 1.7 | **MUROS Y TABIQUES DE ALBAÑILERIA** | 64d | 2005-02-15 | 2005-04-19 |  | 2004-07-14 | 2004-10-26 | 105d | 41d |  |  |
| 85 | 1.7.1 | MURO DE LADRILLO KK TIPO IV SOGA | 20d | 2005-03-16 | 2005-04-04 | 55SS+10d | 2004-07-19 | 2004-08-02 | 15d | 40d | 0d |  |
| 86 | 1.7.2 | MURO DE LADRILLO KK TIPO IV SOGA ACABADO CARAVISTA | 25d | 2005-02-15 | 2005-03-11 | 39FS+4d | 2004-07-19 | 2004-08-02 | 15d | 79d |  |  |
| 87 | 1.7.3 | MURO DE LADRILLO KK TIPO IV CABEZA | 14d | 2005-03-16 | 2005-03-29 | 85SS | 2004-07-19 | 2004-08-02 | 15d | 61d |  |  |
| 88 | 1.7.4 | ALAMBRE DE REFUERZO | 35d | 2005-03-16 | 2005-04-19 | 85SS | 2004-07-19 | 2004-08-02 | 15d | 41d |  |  |
| 89 | 1.8 | **REVOQUES Y ENLUCIDOS** | 64d | 2005-02-06 | 2005-04-10 |  | 2004-09-04 | 2004-10-05 | 31.3d | 50d |  |  |
| 90 | 1.8.1 | TARRAJEO PRIMARIO | 10d | 2005-02-06 | 2005-02-15 | 98FS-5d | 2004-09-04 | 2004-09-09 | 5.4d | 74d | 0d |  |
| 91 | 1.8.2 | TARRAJEO FROTACHADO DE MUROS INTERIORES Y EXTERIORES | 21d | 2005-02-06 | 2005-02-26 | 90SS | 2004-09-05 | 2004-09-20 | 15d | 74d | 0d |  |
| 92 | 1.8.3 | TARRAJEO DE COLUMNAS | 19d | 2005-03-22 | 2005-04-09 | 91FF+7d | 2004-09-20 | 2004-10-05 | 15d | 49d | 0d | start no earlier than 2005-03-22 |
| 93 | 1.8.4 | TARRAJEO DE VIGAS PERALTADAS | 20d | 2005-03-22 | 2005-04-10 | 92SS | 2005-02-26 | 2005-03-03 | 6d | 49d |  |  |
| 94 | 1.8.5 | TARRAJEO CON IMPERMEABILIZANTE | 5d | 2005-02-06 | 2005-02-10 | 68FS+7d | 2005-02-22 | 2005-02-23 | 2d | 109d | 94d |  |
| 95 | 1.8.6 | VESTIDURA DE DERRAMES | 13d | 2005-03-24 | 2005-04-05 | 92SS+2d | 2004-09-13 | 2004-09-28 | 15d | 54d |  |  |
| 96 | 1.8.7 | BRUÑAS SEGÚN DETALLE | 12d | 2005-02-25 | 2005-03-08 | 91FS-2d | 2004-09-20 | 2004-09-22 | 1.9d | 82d |  |  |
| 97 | 1.9 | **CIELORRASOS** | 20d | 2005-01-22 | 2005-02-10 |  | 2004-08-28 | 2004-09-08 | 10.2d | 15d | 0d |  |
| 98 | 1.9.1 | TARRAJEO DE CIELO RASO CON MEZCLA C:A 1:5 | 20d | 2005-01-22 | 2005-02-10 | 60FS-7d | 2004-08-28 | 2004-09-07 | 10d | 15d | 0d |  |
| 99 | 1.10 | **PISOS Y PAVIMENTOS** | 82d | 2005-03-05 | 2005-05-25 |  | 2004-09-29 | 2004-10-15 | 16.3d | 5d |  |  |
| 100 | 1.10.1 | PISO CERAMICA VITRIFICADA | 16d | 2005-04-26 | 2005-05-11 | 105SS+2d | 2004-09-29 | 2004-09-30 | 1.3d | 0d |  |  |
| 101 | 1.10.2 | PISO CEMENTO PULIDO | 20d | 2005-04-26 | 2005-05-15 | 100SS | 2004-10-14 | 2004-10-15 | 1d | 0d |  |  |
| 102 | 1.10.3 | PISO CEMENTO FROTACHADO | 25d | 2005-05-01 | 2005-05-25 | 101SS+5d | 2004-09-30 | 2004-10-15 | 15d | 0d |  |  |
| 103 | 1.10.4 | GRADAS EN PISO | 9d | 2005-05-01 | 2005-05-09 | 102SS | 2005-01-28 | 2005-01-29 | 2d | 12d | 0d |  |
| 104 | 1.10.5 | VEREDA Y RAMPA CONCRETO 140KG/CM2 | 16d | 2005-05-03 | 2005-05-18 | 103SS+2d |  |  |  | 12d |  | start no earlier than 2005-03-20 |
| 105 | 1.10.6 | CONTRAPISO E=40mm | 19d | 2005-04-24 | 2005-05-12 | 41 |  |  |  | 0d |  |  |
| 106 | 1.10.7 | BASE PARA MUEBLE FIJO h=10cm | 2d | 2005-04-29 | 2005-04-30 | 105SS+5d |  |  |  | 30d |  |  |
| 107 | 1.10.8 | AFIRMADO DE 16" PARA PISOS | 12d | 2005-03-05 | 2005-03-16 | 31 |  |  |  | 75d |  |  |

| ID | WBS | Task | Duration | Start | Finish | Predecessors | Baseline start | Baseline finish | Baseline duration | Total slack | Free slack |
| --- | --- | --- | --- | --- | --- | --- | --- | --- | --- | --- | --- |
| 108 | 1.11 | **ZOCALOS Y ENCHAPES** | 17d | 2005-02-21 | 2005-03-09 |  | 2004-10-15 | 2004-10-24 | 9.4d | 65d |  |
| 109 | 1.11.1 | ZOCALO DE CERAMICA VITRIFICADA | 17d | 2005-02-21 | 2005-03-09 | 91FS-6d |  |  |  | 74d | 0d |
| 110 | 1.12 | **CONTRAZOCALOS** | 86d | 2005-02-19 | 2005-05-15 |  | 2004-10-10 | 2004-10-20 | 10d | 15d |  |
| 111 | 1.12.1 | CONTRAZOCALO DE CEMENTO PULIDO | 15d | 2005-05-01 | 2005-05-15 | 102SS | 2004-10-10 | 2004-10-20 | 10d | 15d | 0d |
| 112 | 1.12.2 | CONTRAZOCALO DE CEMENTO PULIDO < 45 | 11d | 2005-02-19 | 2005-03-01 | 114 | 2005-04-10 | 2005-04-10 | 1d | 89d | 59d |
| 113 | 1.13 | **CUBIERTAS** | 13d | 2005-02-06 | 2005-02-18 |  | 2005-03-12 | 2005-03-16 | 5d | 90d |  |
| 114 | 1.13.1 | CUBIERTA DE LADRILLO PASTELERO | 13d | 2005-02-06 | 2005-02-18 | 60FS+8d | 2005-03-12 | 2005-03-16 | 5d | 89d | 0d |
| 115 | 1.14 | **CARPINTERIA DE MADERA** | 13d | 2005-02-25 | 2005-03-09 |  | 2004-10-26 | 2004-11-14 | 20d | 70d |  |
| 116 | 1.14.1 | PUERTAS | 13d | 2005-02-25 | 2005-03-09 | 129SS | 2004-10-26 | 2004-11-12 | 18d | 69d | 0d |
| 117 | 1.14.2 | VENTANAS | 12d | 2005-02-25 | 2005-03-08 | 116SS | 2004-11-14 | 2004-11-14 | 1d | 82d | 0d |
| 118 | 1.15 | **CARPINTERIA METALICA Y HERRERIA** | 11d | 2005-02-28 | 2005-03-10 |  | 2004-11-06 | 2004-11-17 | 11.4d | 70d |  |
| 119 | 1.15.1 | PUERTAS DE FIERRO | 7d | 2005-02-28 | 2005-03-06 | 116SS+3d | 2004-11-06 | 2004-11-12 | 6.3d | 69d | 0d |
| 120 | 1.15.2 | VARIOS | 4d | 2005-03-07 | 2005-03-10 | 119 | 2004-11-10 | 2004-11-12 | 1.8d | 69d | 0d |
| 121 | 1.16 | **CERRAJERIA** | 11d | 2005-03-11 | 2005-03-21 | 120 | 2004-11-12 | 2004-11-17 | 4.5d | 70d |  |
| 122 | 1.16.1 | BISAGRAS | 10d | 2005-03-11 | 2005-03-20 | 116SS+2d | 2004-11-17 | 2004-11-17 | 0.3d | 69d | 0d |
| 123 | 1.16.2 | CERRADURAS | 11d | 2005-03-11 | 2005-03-21 | 122SS | 2005-04-24 | 2005-04-26 | 3d | 69d | 39d |
| 124 | 1.17 | **VIDRIOS, CRISTALES Y SIMILARES** | 10d | 2005-02-25 | 2005-03-06 |  | 2004-11-17 | 2004-11-23 | 6.1d | 85d |  |
| 125 | 1.17.1 | VIDRIO 4mm | 10d | 2005-02-25 | 2005-03-06 | 117SS | 2004-11-17 | 2004-11-21 | 4.5d | 84d | 54d |
| 126 | 1.18 | **PINTURA** | 30d | 2005-02-25 | 2005-03-26 |  | 2004-10-17 | 2004-11-03 | 18d | 15d |  |
| 127 | 1.18.1 | PINTURA LATEX 2 MANOS EN MUROS Y COLUMNA | 26d | 2005-03-01 | 2005-03-26 | 128SS+4d | 2005-08-05 | 2005-08-16 | 8d | 15d | 0d |
| 128 | 1.18.2 | PINTURA LATEX 2 MANOS EN CIELO RASO Y VIGAS | 21d | 2005-02-25 | 2005-03-17 | 97FS+14d, 98 | 2004-10-17 | 2004-10-23 | 7d | 15d | 0d |
| 129 | 1.18.3 | PINTURA BARNIZ | 10d | 2005-02-25 | 2005-03-06 | 128SS | 2004-10-19 | 2004-10-30 | 12d | 69d | 0d |
| 130 | 1.18.4 | PINTURA EN CARPINTERIA METALICA | 4d | 2005-03-07 | 2005-03-10 | 129 |  |  |  | 80d |  |
| 131 | 1.19 | **APARATOS SANITARIOS Y ACCESORIOS** | 7d | 2005-03-10 | 2005-03-16 |  | 2005-04-01 | 2005-04-05 | 4d | 65d |  |
| 132 | 1.19.1 | APARATOS SANITARIOS | 7d | 2005-03-10 | 2005-03-16 | 109 | 2005-04-01 | 2005-04-03 | 2d | 74d | 0d |
| 133 | 1.19.2 | ESPEJO BISELADO | 4d | 2005-03-10 | 2005-03-13 | 132SS | 2005-04-02 | 2005-04-04 | 2d | 77d | 0d |
| 134 | 1.19.3 | PORTARROLLO D PAPEL DE LOZA | 4d | 2005-03-10 | 2005-03-13 | 133SS | 2005-04-03 | 2005-04-05 | 2d | 77d | 47d |

| ID | WBS | Task | Duration | Start | Finish | Predecessors | Baseline start | Baseline finish | Baseline duration | Total slack | Free slack |
| --- | --- | --- | --- | --- | --- | --- | --- | --- | --- | --- | --- |
| 135 | 1.20 | **VARIOS** | 121d | 2005-01-30 | 2005-05-30 |  | 2005-01-01 | 2005-04-30 | 120d | 0d |  |
| 136 | 1.20.1 | LIMPIEZA PERMANENTE DE LA OBRA | 15d | 2005-05-15 | 2005-05-29 | 176FF-1d | 2005-03-12 | 2005-03-13 | 2d | 1d | 0d |
| 137 | 1.20.2 | PASAMANO DE ESCALERA DE FºGº DE 2" | 12d | 2005-04-01 | 2005-04-12 | 77 |  |  |  | 48d |  |
| 138 | 1.20.3 | BARRA DE APOYO PERSONAS DISCAPACITADAS | 10d | 2005-03-17 | 2005-03-26 | 132 |  |  |  | 65d |  |
| 139 | 1.20.4 | ESCALERA METALICA TIPO CARACOL S/DISEÑO | 10d | 2005-03-26 | 2005-04-04 | 59 |  |  |  | 53d | 0d |
| 140 | 1.20.5 | ESCALERA DE GATO A TANQUE ELEVADO C/TUBO Fe.Ne. PINTADO AL ESMALTE S/DISEÑO | 7d | 2005-01-30 | 2005-02-05 | 68 |  |  |  | 114d |  |
| 141 | 1.20.6 | TAPAJUNTA DE METALICA DE 4"x1"x1/4" S/DISEÑO | 5d | 2005-05-26 | 2005-05-30 | 102 |  |  |  | 0d |  |
| 142 | 1.20.7 | TAPAJUNTA DE FºGº P/CERRAMIENTO S/DISEÑO | 5d | 2005-05-26 | 2005-05-30 | 102 |  |  |  | 0d |  |
| 143 | 1.20.8 | TAPAJUNTA DE METAL DE 4" x 3/16" S/DISEÑO | 5d | 2005-05-26 | 2005-05-30 | 102 |  |  |  | 0d |  |
| 144 | 1.20.9 | SUMINISTRO E INSTALACION PROTECTOR METALICO TRIPUNTA INC. ANTICORROSIVO + PINTURA | 20d | 2005-03-04 | 2005-03-23 | 4SS+60d |  |  |  | 68d | 0d |
| 145 | 1.20.10 | RESANE DE MUROS Y PARAPETOS MORT. 1:4, e=1.50cm | 5d | 2005-03-04 | 2005-03-08 | 144SS |  |  |  | 83d | 0d |
| 146 | 1.20.11 | RESANE DE PISOS DE CONCRETO FROTACHADO E=2.5 cm | 5d | 2005-03-04 | 2005-03-08 | 145SS |  |  |  | 83d |  |
| 147 | 1.20.12 | REHABILITACION DE MUROS CARAVISTA CON SALITRE | 10d | 2005-03-04 | 2005-03-13 | 144SS |  |  |  | 78d |  |
| 148 | 1.20.13 | LIMPIEZA DE VENTANAS Y VIDRIOS | 10d | 2005-05-15 | 2005-05-24 | 136FS-15d |  |  |  | 6d |  |
| 149 | 1.20.14 | SUMINISTRO E INSTALACION DE TABLEROS DE BASQUET | 3d | 2005-04-05 | 2005-04-07 | 139 |  |  |  | 53d |  |
| 150 | 1.21 | **INSTALACIONES ELECTRICAS** | 43d | 2005-04-10 | 2005-05-22 |  | 2004-07-14 | 2004-10-30 | 108.4d | 8d |  |
| 151 | 1.21.1 | ARTEFACTOS DE ILUMINACION | 11d | 2005-05-11 | 2005-05-21 | 152FS-4d | 2004-07-14 | 2004-07-25 | 11.2d | 9d |  |
| 152 | 1.21.2 | INTERRUPTORES Y TOMACORRIENTES | 16d | 2005-04-29 | 2005-05-14 | 153 | 2004-07-25 | 2004-07-27 | 2.8d | 9d | 0d |
| 153 | 1.21.3 | CAJAS DE PASE | 12d | 2005-04-17 | 2005-04-28 | 154SS+7d |  |  |  | 9d | 0d |
| 154 | 1.21.4 | TUBERIAS Y ACCESORIOS DE PVC | 22d | 2005-04-10 | 2005-05-01 | 41SS+5d |  |  |  | 8d | 0d |
| 155 | 1.21.5 | CABLES Y CONDUCTORES | 5d | 2005-04-29 | 2005-05-03 | 154FS-3d |  |  |  | 8d | 0d |
| 156 | 1.21.6 | TABLEROS | 16d | 2005-05-07 | 2005-05-22 | 155FS+3d |  |  |  | 8d | 0d |
| 157 | 1.21.7 | SALIDAS | 10d | 2005-04-29 | 2005-05-08 | 153 |  |  |  | 22d |  |
| 158 | 1.21.8 | OTROS | 9d | 2005-04-29 | 2005-05-07 | 155SS |  |  |  | 23d |  |
| 159 | 1.21.9 | VARIOS | 5d | 2005-04-29 | 2005-05-03 | 153 |  |  |  | 27d |  |
| 160 | 1.21.10 | PRUEBAS ELECTRICAS | 2d | 2005-05-07 | 2005-05-08 | 156SS |  |  |  | 22d |  |

| ID | WBS | Task | Type | Duration | Start | Finish | Predecessors | Baseline start | Baseline finish | Baseline duration | Total slack | Free slack | Constraint |
| --- | --- | --- | --- | --- | --- | --- | --- | --- | --- | --- | --- | --- | --- |
| 161 | 1.22 | **SISTEMA DE DESAGUE Y VENTILACION** |  | 18d | 2005-04-18 | 2005-05-05 |  | 2004-07-14 | 2004-09-03 | 52d | 25d |  |  |
| 162 | 1.22.1 | SALIDA DE DESAGUE |  | 10d | 2005-04-24 | 2005-05-03 | 164 | 2004-07-14 | 2004-07-17 | 3.8d | 25d | 0d |  |
| 163 | 1.22.2 | SALIDA DE VENTILACION |  | 10d | 2005-04-26 | 2005-05-05 | 162SS+2d |  |  |  | 25d |  | start no earlier than 2005-01-16 |
| 164 | 1.22.3 | TUBERIAS DE DESAGUE Y VENTILACION |  | 6d | 2005-04-18 | 2005-04-23 | 41FS-6d |  |  |  | 25d | 0d |  |
| 165 | 1.22.4 | ACCESORIOS PARA REDES |  | 5d | 2005-04-18 | 2005-04-22 | 164SS |  |  |  | 38d |  |  |
| 166 | 1.22.5 | CAJAS DE REGISTRO |  | 10d | 2005-04-21 | 2005-04-30 | 164FS-3d |  |  |  | 26d | 0d |  |
| 167 | 1.22.6 | VARIOS |  | 12d | 2005-04-23 | 2005-05-04 | 166SS+2d | 2004-07-17 | 2004-07-20 | 2.8d | 26d |  |  |
| 168 | 1.23 | **SISTEMA DE AGUA FRIA** |  | 36d | 2005-04-10 | 2005-05-15 |  | 2004-07-14 | 2004-08-01 | 18.1d | 12d |  |  |
| 169 | 1.23.1 | SALIDAS DE AGUA FRIA |  | 20d | 2005-04-20 | 2005-05-09 | 170FS-8d | 2004-07-25 | 2004-08-01 | 6.7d | 12d | 0d |  |
| 170 | 1.23.2 | TUBERIA PVC PARA AGUA FRIA |  | 18d | 2005-04-10 | 2005-04-27 | 41SS+5d |  |  |  | 12d | 0d |  |
| 171 | 1.23.3 | ACCESORIOS PARA REDES |  | 16d | 2005-04-13 | 2005-04-28 | 170SS+3d |  |  |  | 32d |  | start no earlier than 2004-12-30 |
| 172 | 1.23.4 | VALVULAS |  | 8d | 2005-04-15 | 2005-04-22 | 170SS+5d |  |  |  | 38d |  |  |
| 173 | 1.23.5 | VARIOS |  | 9d | 2005-05-07 | 2005-05-15 | 169FS-3d | 2004-07-14 | 2004-07-18 | 4.3d | 12d | 0d |  |
| 174 | 1.24 | **PRUEBA HIDRAULICA Y DESINFECCION** |  | 3d | 2005-05-16 | 2005-05-18 |  | 2004-10-30 | 2004-12-07 | 38.6d | 12d |  |  |
| 175 | 1.24.1 | PRUERBAS VARIAS |  | 3d | 2005-05-16 | 2005-05-18 | 173 | 2004-10-30 | 2004-10-30 | 0.5d | 12d |  | start no earlier than 2005-03-21 |
| 176 | 1.25 | **MOBILIARIO** |  | 39d | 2005-04-22 | 2005-05-30 |  | 2005-04-21 | 2005-04-28 | 8d | 0d |  |  |
| 177 | 1.25.1 | MOBILIARIO |  | 24d | 2005-04-22 | 2005-05-15 | 127FS+26d | 2005-04-21 | 2005-04-25 | 5d | 15d |  |  |
| 178 | 1.25.2 | FIN DE OBRA | milestone | 0d | 2005-05-30 | 2005-05-30 | 141 | 2004-12-07 | 2004-12-07 | 0d | 0d |  |  |
